# Build Plan

Schedule from MS Project, 2015-01-05 to 2015-02-19, 3 hours a day.
Daniel Webster College

## Calendars

- Standard: Mon-Tue 18:30-21:30; Wed off; Thu-Fri 18:30-21:30; Sat 10:00-12:00, 13:00-17:00; Sun 13:00-18:00. Exceptions (off unless hours are given): 2015-01-24 (Snow Day), 2015-01-27 (Snow Day), 2015-01-28 18:30-21:30 (Snow Day Makeup), 2015-02-02 (Snow Day), 2015-02-04 18:30-21:30 (Snow Day Makeup).

## Schedule

| ID | WBS | Task | Duration | Start | Finish | Predecessors | Total slack | Free slack | Constraint |
| --- | --- | --- | --- | --- | --- | --- | --- | --- | --- |
| 1 | 1 | **Prototyping / Build Preparation** | 3.33d | 2015-01-05 18:30 | 2015-01-09 19:30 |  | 2d | 0d |  |
| 2 | 1.1 | Hook Prototype | 8h | 2015-01-05 18:30 | 2015-01-08 20:30 |  | 2.33d | 0d |  |
| 3 | 1.2 | Arm Prototype | 8h | 2015-01-05 18:30 | 2015-01-08 20:30 |  | 2.33d | 0d |  |
| 4 | 1.3 | Temp Control Board | 3h | 2015-01-05 18:30 | 2015-01-05 21:30 |  | 2.33d | 0d |  |
| 5 | 1.4 | Build Base | 6h | 2015-01-05 18:30 | 2015-01-06 21:30 |  | 2d | 0d |  |
| 6 | 1.5 | Choose Attachment Design | 1h | 2015-01-08 20:30 | 2015-01-08 21:30 | 2, 3 | 2.33d |  |  |
| 7 | 1.6 | **Software** | 1d | 2015-01-05 18:30 | 2015-01-05 21:30 |  | 2.33d | 1.33d |  |
| 8 | 1.6.1 | RoboRio Firmware | 3h | 2015-01-05 18:30 | 2015-01-05 21:30 |  | 2.33d | 0d |  |
| 9 | 1.6.2 | Radio Config. | 3h | 2015-01-05 18:30 | 2015-01-05 21:30 |  | 3.33d |  |  |
| 10 | 1.6.3 | Drive Station Config. | 3h | 2015-01-05 18:30 | 2015-01-05 21:30 |  | 3.33d |  |  |
| 11 | 1.7 | Test Motors | 3h | 2015-01-06 18:30 | 2015-01-06 21:30 | 4, 8 | 2.33d | 0.33d |  |
| 12 | 1.8 | Mount Temp Control Board | 1h | 2015-01-08 18:30 | 2015-01-08 19:30 | 4, 5 | 2d | 0d |  |
| 13 | 1.9 | Test Base | 3h | 2015-01-08 19:30 | 2015-01-09 19:30 | 4, 5, 7, 11, 12 | 2d |  |  |
| 14 | 1.10 | Dragger Prototype | 10h | 2015-01-05 18:30 | 2015-01-09 19:30 |  | 2d |  |  |
| 15 | 2 | **Create Robot 1** | 30.33d? | 2015-01-09 19:30 | 2015-02-07 14:00 | 1 | 2d |  |  |
| 16 | 2.1 | **Drive Train 1** | 6.33d | 2015-01-09 19:30 | 2015-01-13 21:30 |  | 23d |  |  |
| 17 | 2.1.1 | Design Drive Train 1 | 8h | 2015-01-09 19:30 | 2015-01-10 17:00 |  | 20d | 0d |  |
| 18 | 2.1.2 | Build Drive Train 1 | 5h | 2015-01-11 13:00 | 2015-01-11 18:00 | 17 | 20d | 0d |  |
| 19 | 2.1.3 | Assemble Drive Train 1 | 6h | 2015-01-12 18:30 | 2015-01-13 21:30 | 18 | 20d | 0d | start no earlier than 2015-01-12 18:30 |
| 20 | 2.2 | **Test Attachment** | 11.33d | 2015-01-11 13:00 | 2015-01-20 21:30 | 35, 2, 3 | 0d |  |  |
| 21 | 2.2.1 | Design Test Attachment | 11h | 2015-01-11 13:00 | 2015-01-13 21:30 |  | 0d |  | start no earlier than 2015-01-10 18:30 |
| 22 | 2.2.2 | Build Test Attachment | 6h | 2015-01-15 18:30 | 2015-01-16 21:30 | 21 | 0d |  |  |
| 23 | 2.2.3 | Assemble Test Attachment | 11h | 2015-01-17 10:00 | 2015-01-18 18:00 | 22 | 20d | 0d |  |
| 24 | 2.2.4 | Mount Test Attachment | 6h | 2015-01-19 18:30 | 2015-01-20 21:30 | 19, 23 | 20d | 0d |  |

| ID | WBS | Task | Duration | Start | Finish | Predecessors | Total slack | Free slack | Constraint |
| --- | --- | --- | --- | --- | --- | --- | --- | --- | --- |
| 25 | 2.3 | **Attachment 1** | 24d | 2015-01-15 18:30 | 2015-02-07 14:00 |  | 2d |  |  |
| 26 | 2.3.1 | Code Attachment | 20h | 2015-01-15 18:30 | 2015-01-19 21:30 | 21 | 15.67d | 9.67d |  |
| 27 | 2.3.2 | Design Attachment 1 | 28h | 2015-01-17 10:00 | 2015-01-25 18:00 | 22 | 0d |  |  |
| 28 | 2.3.3 | Build Attachment 1 | 17h | 2015-01-26 18:30 | 2015-01-31 16:00 | 27 | 0d |  |  |
| 29 | 2.3.4 | Assemble Attachment 1 | 18h | 2015-01-31 16:00 | 2015-02-06 21:30 | 28 | 0d |  |  |
| 30 | 2.3.5 | Mount Attachment | 3h | 2015-02-07 10:00 | 2015-02-07 14:00 | 29 | 0d |  |  |
| 31 | 2.4 | **Dragger 1** | 8.67d | 2015-01-25 13:00 | 2015-02-01 16:00 |  | 19d |  |  |
| 32 | 2.4.1 | Build Dragger 1 | 5h | 2015-01-25 13:00 | 2015-01-25 18:00 |  | 16.67d | 3d | start no earlier than 2015-01-24 18:30 |
| 33 | 2.4.2 | Mount Dragger 1 | 3h | 2015-02-01 13:00 | 2015-02-01 16:00 | 32 | 18d |  | start no earlier than 2015-01-31 18:30 |
| 34 | 2.5 | **Control Panel 1** | 8.33d? | 2015-01-09 19:30 | 2015-01-16 21:30 |  | 2d |  |  |
| 35 | 2.5.1 | Decide Control Board Volume | 2h | 2015-01-09 19:30 | 2015-01-09 21:30 |  | 2d | 0d | start no earlier than 2015-01-09 18:30 |
| 36 | 2.5.2 | Build Control Panel 1 | 17h | 2015-01-10 10:00 | 2015-01-13 21:30 | 35 | 20d | 0d |  |
| 37 | 2.5.3 | Mount Control Panel 1 | 6h? | 2015-01-15 18:30 | 2015-01-16 21:30 | 36, 19 | 20d | 0d |  |
| 38 | 3 | **Create Robot 2** | 28.67d? | 2015-01-17 10:00 | 2015-02-13 21:30 |  | 6.67d |  |  |
| 39 | 3.1 | **Drive Train 2** | 7.67d? | 2015-01-17 10:00 | 2015-01-23 21:30 |  | 20d |  |  |
| 40 | 3.1.1 | Build Drive Train 2 | 11h | 2015-01-17 10:00 | 2015-01-18 18:00 | 22 | 11.67d | 0d |  |
| 41 | 3.1.2 | Assemble Drive Train 2 | 12h? | 2015-01-19 18:30 | 2015-01-23 21:30 | 40 | 11.67d | 0d |  |
| 42 | 3.2 | **Attachment 2** | 6.67d | 2015-02-07 14:00 | 2015-02-13 21:30 |  | 0d |  |  |
| 43 | 3.2.1 | Build Attachment 2 | 6h | 2015-02-07 14:00 | 2015-02-08 16:00 | 30 | 0d |  |  |
| 44 | 3.2.2 | Assemble Attachment 2 | 11h | 2015-02-08 16:00 | 2015-02-12 21:30 | 43 | 0d |  |  |
| 45 | 3.2.3 | Mount Attachment 2 | 3h | 2015-02-13 18:30 | 2015-02-13 21:30 | 44 | 0d |  |  |
| 46 | 3.3 | **Dragger 2** | 2d | 2015-02-07 10:00 | 2015-02-07 17:00 |  | 12.33d |  |  |
| 47 | 3.3.1 | Build Dragger 2 | 3h | 2015-02-07 10:00 | 2015-02-07 14:00 | 29 | 13.33d |  |  |
| 48 | 3.3.2 | Mount Dragger 2 | 3h | 2015-02-07 14:00 | 2015-02-07 17:00 | 30 | 12.33d |  |  |

| ID | WBS | Task | Duration | Start | Finish | Predecessors | Total slack | Free slack |
| --- | --- | --- | --- | --- | --- | --- | --- | --- |
| 49 | 3.4 | **Control Panel 2** | 8.67d | 2015-01-17 10:00 | 2015-01-25 16:00 |  | 20d |  |
| 50 | 3.4.1 | Build Control Panel 2 | 14h | 2015-01-17 10:00 | 2015-01-19 21:30 | 37 | 20d | 3d |
| 51 | 3.4.2 | Mount Control Panel 2 | 3h | 2015-01-25 13:00 | 2015-01-25 16:00 | 50, 41 | 17d | 0d |
| 52 | 4 | **Testing** | 35.33d | 2015-01-17 10:00 | 2015-02-19 21:30 |  | 0d |  |
| 53 | 4.1 | Test Drive Train 1 | 20h | 2015-01-17 10:00 | 2015-01-22 21:30 | 19, 37 | 20.33d |  |
| 54 | 4.2 | Test Test Attachment | 20h | 2015-01-22 18:30 | 2015-01-29 21:30 | 24, 37 | 14.67d |  |
| 55 | 4.3 | Test Attachment 1 | 20h | 2015-02-07 14:00 | 2015-02-13 21:30 | 37, 30, 26 | 6.67d |  |
| 56 | 4.4 | Test Drive Train 2 | 20h | 2015-01-25 16:00 | 2015-01-31 17:00 | 41, 51 | 11.67d |  |
| 57 | 4.5 | Test Attachment 2 | 20h | 2015-02-14 10:00 | 2015-02-19 21:30 | 51, 45, 26 | 0d |  |
